# Gantt chart - Caldera_V4

Schedule from MS Project, 2024-07-25 to 2030-09-25.

## Calendars

- Estándar: Mon-Fri 09:00-13:00, 15:00-19:00; Sat-Sun off.

## Schedule

| ID | WBS | Task | Type | Duration | Start | Finish | Predecessors | Total slack | Free slack | Constraint |
| --- | --- | --- | --- | --- | --- | --- | --- | --- | --- | --- |
| 1 | 1 | **PROGRAMA MAESTRO CONCESIÓN PUERTO CALDERA** |  | 1610d | 2024-07-25 | 2030-09-25 |  | 0d |  |  |
| 2 | 1.1 | **0. Hitos Principales** |  | 1580d | 2024-07-25 | 2030-08-14 |  | 30d |  |  |
| 3 | 1.1.1 | 0.1. Definición concesionario | milestone | 0d | 2026-02-27 | 2026-02-27 | 16 | 1193d |  |  |
| 4 | 1.1.2 | 0.2. Licencia ambiental | milestone | 0d | 2027-03-24 | 2027-03-24 | 29 | 915d |  |  |
| 5 | 1.1.3 | 0.3. Selección Empresa EPC por concesionario | milestone | 0d | 2026-05-12 | 2026-05-12 | 36 | 1141d |  |  |
| 6 | 1.1.4 | 0.4. Inicio trabajos en Puerto Caldera Fase 1 | milestone | 0d | 2026-12-22 | 2026-12-22 | 58SS | 982d |  |  |
| 7 | 1.1.5 | 0.5. Término de dragados fase 1 | milestone | 0d | 2027-10-11 | 2027-10-11 | 85 | 772d |  |  |
| 8 | 1.1.6 | 0.6. Termino fase 1 Terminal de Contenedores | milestone | 0d | 2030-08-14 | 2030-08-14 | 187 | 30d |  |  |
| 9 | 1.1.7 | 0.7. Termino ampliación Terminal de Graneles | milestone | 0d | 2028-11-03 | 2028-11-03 | 179 | 493d |  |  |
| 10 | 1.1.8 | 0.8. Termino fase unica Terminal de Carga General | milestone | 0d | 2029-04-23 | 2029-04-23 | 191 | 372d |  |  |
| 11 | 1.1.9 | 0.9. Inicio operación por Concesionario | milestone | 0d | 2030-08-14 | 2030-08-14 | 179, 187, 191 | 30d |  |  |
| 12 | 1.1.10 | 0.10. Término fase 2 Terminal de contenedores | milestone | 0d | 2024-07-25 | 2024-07-25 |  | 1610d |  |  |
| 13 | 1.2 | **1. Actividades iniciales proyecto** |  | 270d | 2025-02-17 | 2026-02-27 |  | 0d |  |  |
| 14 | 1.2.1 | 1.1. Término ingeniería conceptual | milestone | 0d | 2025-02-17 | 2025-02-17 |  | 0d |  | start no earlier than 2025-02-17 |
| 15 | 1.2.2 | 1.2. Proceso de Licitación y Definición de concesionario |  | 270d | 2025-02-17 | 2026-02-27 | 14 | 0d |  |  |
| 16 | 1.2.3 | 1.3. Inicio proyecto por concesionario | milestone | 0d | 2026-02-27 | 2026-02-27 | 15 | 0d |  | start no earlier than 2025-11-03 |
| 17 | 1.3 | **2. Estudios y permisos ambientales** |  | 278d | 2026-03-02 | 2027-03-24 |  | 74d |  |  |
| 18 | 1.3.1 | **2.1. Licitación Empresa para estudios de licencia ambiental** |  | 66d | 2026-03-02 | 2026-06-01 |  | 74d |  |  |
| 19 | 1.3.1.1 | 2.1.1. Confección Bases de licitación ambiental |  | 20d | 2026-03-02 | 2026-03-27 | 16 | 74d | 0d |  |
| 20 | 1.3.1.2 | 2.1.2. Llamado a empresas ambientales |  | 5d | 2026-03-30 | 2026-04-03 | 19 | 1168d |  |  |
| 21 | 1.3.1.3 | 2.1.3. Entrega de bases |  | 5d | 2026-03-30 | 2026-04-03 | 19 | 74d | 0d |  |
| 22 | 1.3.1.4 | 2.1.4. Proceso de Licitación |  | 40d | 2026-04-06 | 2026-05-29 | 21 | 74d | 0d |  |
| 23 | 1.3.1.5 | 2.1.5. Selección final empresa |  | 1d | 2026-06-01 | 2026-06-01 | 22 | 74d | 0d |  |
| 24 | 1.3.2 | **2.2. Estudio ambiental** |  | 212d | 2026-06-02 | 2027-03-24 |  | 74d |  |  |
| 25 | 1.3.2.1 | 2.2.1. Estudios de campo |  | 180d | 2026-06-02 | 2027-02-08 | 23 | 74d | 0d |  |
| 26 | 1.3.2.2 | 2.2.2. Confección informe ambiental para licencia |  | 90d | 2026-08-25 | 2026-12-28 | 25SS+60d | 74d | 0d |  |
| 27 | 1.3.2.3 | 2.2.3. Entrega informe ambiental a autoridad ambiental |  | 1d | 2026-12-29 | 2026-12-29 | 26 | 74d | 0d |  |
| 28 | 1.3.2.4 | 2.2.4. Proceso de licencia ambiental |  | 60d | 2026-12-30 | 2027-03-23 | 27 | 74d | 0d |  |
| 29 | 1.3.2.5 | 2.2.5. Licencia ambiental |  | 1d | 2027-03-24 | 2027-03-24 | 28 | 74d | 0d |  |

| ID | WBS | Task | Type | Duration | Start | Finish | Predecessors | Total slack | Free slack |
| --- | --- | --- | --- | --- | --- | --- | --- | --- | --- |
| 30 | 1.4 | **3. Gestión de selección EPC y adquisición equipos principales** |  | 593d | 2026-03-02 | 2028-06-07 |  | 0d |  |
| 31 | 1.4.1 | **3.1. Selección EPC** |  | 52d | 2026-03-02 | 2026-05-12 |  | 29d |  |
| 32 | 1.4.1.1 | 3.1.1. Confección Bases de licitación EPC |  | 20d | 2026-03-02 | 2026-03-27 | 16 | 29d | 0d |
| 33 | 1.4.1.2 | 3.1.2. Llamado a licitación empresas EPC |  | 10d | 2026-03-16 | 2026-03-27 | 32FF | 29d | 0d |
| 34 | 1.4.1.3 | 3.1.3. Entrega de bases e ingeniería básica |  | 1d | 2026-03-30 | 2026-03-30 | 33 | 29d | 0d |
| 35 | 1.4.1.4 | 3.1.4. Proceso de Licitación |  | 30d | 2026-03-31 | 2026-05-11 | 34 | 29d | 0d |
| 36 | 1.4.1.5 | 3.1.5. Selección final empresa EPC (entrega carta de intención o contrato) |  | 1d | 2026-05-12 | 2026-05-12 | 35 | 29d | 0d |
| 37 | 1.4.2 | **3.2. Adquisición equipos principales** |  | 512d | 2026-06-23 | 2028-06-07 |  | 0d |  |
| 38 | 1.4.2.1 | 3.2.1. Confección Bases de adquisición |  | 90d | 2026-06-23 | 2026-10-26 | 36, 48 | 0d |  |
| 39 | 1.4.2.2 | 3.2.2. Llamado a empresas suministradoras (Vendor) |  | 60d | 2026-10-27 | 2027-01-18 | 38 | 0d |  |
| 40 | 1.4.2.3 | 3.2.3. Entrega de bases de adquisición |  | 1d | 2027-01-19 | 2027-01-19 | 39, 38 | 0d |  |
| 41 | 1.4.2.4 | 3.2.4. Proceso de Licitación |  | 120d | 2027-01-20 | 2027-07-06 | 40 | 0d |  |
| 42 | 1.4.2.5 | 3.2.5. Selección final empresa(s) vendor |  | 1d | 2027-07-07 | 2027-07-07 | 41, 29 | 0d |  |
| 43 | 1.4.2.6 | 3.2.6. Fabricación y Traslado equipos a sitio |  | 240d | 2027-07-08 | 2028-06-07 | 42 | 0d |  |
| 44 | 1.5 | **4. Actividades de Gestión del concesionario y de la empresa EPC** |  | 1193d | 2026-03-02 | 2030-09-25 |  | 0d |  |
| 45 | 1.5.1 | **4.1. Ingeniería básica por Concesionario** |  | 81d | 2026-03-02 | 2026-06-22 |  | 0d |  |
| 46 | 1.5.1.1 | 4.1.1. Selección empresa ingeniería |  | 20d | 2026-03-02 | 2026-03-27 | 16 | 0d |  |
| 47 | 1.5.1.2 | 4.1.2. Elaboración ingeniería básica |  | 60d | 2026-03-30 | 2026-06-19 | 46 | 0d |  |
| 48 | 1.5.1.3 | 4.1.3 Término ingeniería básica |  | 1d | 2026-06-22 | 2026-06-22 | 47 | 0d |  |
| 49 | 1.5.2 | **4.2. Control del proyecto (Inspección técnica-PMO)** |  | 1112d | 2026-06-23 | 2030-09-25 |  | 0d |  |
| 50 | 1.5.2.1 | 4.2.1. Selección empresa PMO |  | 20d | 2026-06-23 | 2026-07-20 | 16, 38SS, 48 | 192d |  |
| 51 | 1.5.2.2 | 4.2.2. Apoyo PMO en procesos adquisición equipos y EPC |  | 900d | 2027-04-15 | 2030-09-25 | 50, 175FF | 0d |  |
| 52 | 1.5.3 | **4.3. Ingeniería de detalle por EPC** |  | 160d | 2026-06-23 | 2027-02-01 |  | 47d |  |
| 53 | 1.5.3.1 | 4.3.1. Selección empresa ingeniería |  | 10d | 2026-06-23 | 2026-07-06 | 36, 48 | 47d | 0d |
| 54 | 1.5.3.2 | 4.3.2. Elaboración ingeniería detalle |  | 150d | 2026-07-07 | 2027-02-01 | 53 | 47d | 0d |
| 55 | 1.5.3.3 | 4.3.3 Término ingeniería detalle | milestone | 0d | 2027-02-01 | 2027-02-01 | 54 | 47d | 0d |

| ID | WBS | Task | Type | Duration | Start | Finish | Predecessors | Total slack | Free slack |
| --- | --- | --- | --- | --- | --- | --- | --- | --- | --- |
| 56 | 1.6 | **5. Obras Generales** |  | 440d | 2026-09-01 | 2028-05-08 |  | 75d |  |
| 57 | 1.6.1 | **5.1. Movilización (incluye dragado)** |  | 30d | 2026-12-22 | 2027-02-01 |  | 77d | 0d |
| 58 | 1.6.1.1 | 5.1.1. Movilización |  | 30d | 2026-12-22 | 2027-02-01 | 36, 54FF | 77d | 0d |
| 59 | 1.6.1.2 | 5.1.2. Instalación de faenas |  | 30d | 2026-12-22 | 2027-02-01 | 58SS | 77d | 0d |
| 60 | 1.6.2 | **5.2. Cerco Perimetral** |  | 115d | 2027-02-02 | 2027-07-12 |  | 837d |  |
| 61 | 1.6.2.1 | 5.2.1. Suministro cerco y portones |  | 40d | 2027-02-02 | 2027-03-29 | 58, 59 | 837d | 0d |
| 62 | 1.6.2.2 | 5.2.2. Instalación cerco y portones |  | 60d | 2027-03-30 | 2027-06-21 | 61 | 837d | 0d |
| 63 | 1.6.2.3 | 5.2.3. Instalación CCTV en cerco |  | 60d | 2027-04-20 | 2027-07-12 | 62SS+15d | 837d |  |
| 64 | 1.6.3 | 5.3. Excavaciones instalaciones | manual | 80d | 2026-12-15 | 2027-04-05 | 57 |  |  |
| 65 | 1.6.4 | **5.3. Sistema eléctrico** |  | 330d | 2027-02-02 | 2028-05-08 |  | 622d |  |
| 66 | 1.6.4.1 | 5.3.1 Suministro equipos subestación, transformadores y cables |  | 180d | 2027-02-02 | 2027-10-11 | 57 | 622d | 0d |
| 67 | 1.6.4.2 | 5.3.2. Instalación subestación |  | 60d | 2027-10-12 | 2028-01-03 | 66, 58, 59 | 712d |  |
| 68 | 1.6.4.3 | 5.3.3. Canalización sistemas de fuerza |  | 120d | 2027-10-12 | 2028-03-27 | 64, 66 | 622d | 0d |
| 69 | 1.6.4.4 | 5.3.4. Cableado y conexiones a enchufes reefers |  | 120d | 2027-11-23 | 2028-05-08 | 68SS+30d | 622d |  |
| 70 | 1.6.5 | **5.4. Sistema de alcantarillado y aguas lluvias** |  | 159d | 2027-02-02 | 2027-09-10 |  | 793d |  |
| 71 | 1.6.5.1 | 5.4.1. Excavaciones |  | 54d | 2027-02-02 | 2027-04-16 | 58, 59 | 793d | 0d |
| 72 | 1.6.5.2 | 5.4.2. Instalacion cañerías y ductos |  | 90d | 2027-02-23 | 2027-06-28 | 71SS+15d | 793d | 0d |
| 73 | 1.6.5.3 | 5.4.3. Rellenos |  | 54d | 2027-06-29 | 2027-09-10 | 72 | 793d |  |
| 74 | 1.6.6 | **5.5. Sistema de agua potable** |  | 63d | 2027-02-02 | 2027-04-29 |  | 889d |  |
| 75 | 1.6.6.1 | 5.5.1. Excavaciones |  | 54d | 2027-02-02 | 2027-04-16 | 58, 59 | 889d | 0d |
| 76 | 1.6.6.2 | 5.5.2. Instalación cañerías y válvulas |  | 30d | 2027-02-23 | 2027-04-05 | 75SS+15d | 889d | 0d |
| 77 | 1.6.6.3 | 5.5.3. Rellenos |  | 18d | 2027-04-06 | 2027-04-29 | 76 | 889d |  |
| 78 | 1.6.7 | **5.6. Sistema de red contra incendios** |  | 63d | 2027-02-02 | 2027-04-29 |  | 889d |  |
| 79 | 1.6.7.1 | 5.6.1. Excavaciones |  | 54d | 2027-02-02 | 2027-04-16 | 58, 59 | 889d | 0d |
| 80 | 1.6.7.2 | 5.6.2. Instalación cañerías, válvulas y grifos |  | 30d | 2027-02-23 | 2027-04-05 | 79SS+15d | 889d | 0d |
| 81 | 1.6.7.3 | 5.6.3. Rellenos |  | 18d | 2027-04-06 | 2027-04-29 | 80 | 889d |  |

| ID | WBS | Task | Duration | Start | Finish | Predecessors | Total slack | Free slack |
| --- | --- | --- | --- | --- | --- | --- | --- | --- |
| 82 | 1.6.8 | **5.7. Edificio de operarios y camarines** | 75d | 2027-02-02 | 2027-05-17 |  | 877d |  |
| 83 | 1.6.8.1 | 5.7.1. Excavación y fundaciones | 30d | 2027-02-02 | 2027-03-15 | 58, 59 | 877d | 0d |
| 84 | 1.6.8.2 | 5.7.2. Instalación y conexiones edificio | 45d | 2027-03-16 | 2027-05-17 | 83 | 877d |  |
| 85 | 1.6.9 | 5.8. Dragados generales | 180d | 2027-02-02 | 2027-10-11 | 59 | 772d | 0d |
| 86 | 1.6.10 | 5.9 Suministro de pilotes | 150d | 2026-09-01 | 2027-03-29 | 54SS+40d | 127d | 50d |
| 87 | 1.7 | **6. Fase 1 Terminal de Contenedores Primera mitad (300 m aproximadamente)** | 452d | 2027-02-02 | 2028-10-25 |  | 0d |  |
| 88 | 1.7.1 | **6.1. Demoliciones** | 40d | 2027-02-02 | 2027-03-29 |  | 47d |  |
| 89 | 1.7.1.1 | 6.1.1. Demolición de bodegas | 40d | 2027-02-02 | 2027-03-29 | 55 | 112d | 0d |
| 90 | 1.7.1.2 | 6.1.2. Desarme frente de atraque (Incl. Defensas existentes) | 30d | 2027-02-02 | 2027-03-15 | 55 | 47d | 0d |
| 91 | 1.7.2 | **6.2. Pavimentos** | 165d | 2027-03-30 | 2027-11-15 |  | 47d | 0d |
| 92 | 1.7.2.1 | 6.2.1. Tratamiento y demolición de pavimentos | 100d | 2027-03-30 | 2027-08-16 | 89 | 112d |  |
| 93 | 1.7.2.2 | 6.2.2. Pavimentos (circulación interna) | 65d | 2027-08-17 | 2027-11-15 | 101 | 47d |  |
| 94 | 1.7.2.3 | 6.2.3. Pavimentos (patio contenedores) | 65d | 2027-08-17 | 2027-11-15 | 101 | 47d |  |
| 95 | 1.7.3 | **6.3. Nuevo frente de atraque** | 280d | 2027-03-16 | 2028-04-10 |  | 47d |  |
| 96 | 1.7.3.1 | 6.3.1. Hinca pilotes | 190d | 2027-03-16 | 2027-12-06 | 90, 57, 86SS+50d | 47d | 0d |
| 97 | 1.7.3.2 | 6.3.2. Confección losa hormigón | 200d | 2027-04-27 | 2028-01-31 | 96SS+30d | 102d | 0d |
| 98 | 1.7.3.3 | 6.3.3. Colocación defensas | 50d | 2028-02-01 | 2028-04-10 | 97 | 142d |  |
| 99 | 1.7.3.4 | 6.3.4. Colocación bitas | 10d | 2028-02-01 | 2028-02-14 | 97 | 182d |  |
| 100 | 1.7.4 | **6.4. Relleno explanada** | 200d | 2027-04-06 | 2028-01-10 |  | 62d |  |
| 101 | 1.7.4.1 | 6.4.1. Relleno explanada | 80d | 2027-04-27 | 2027-08-16 | 96SS+30d | 47d | 0d |
| 102 | 1.7.4.2 | 6.4.2. Enrocado protección | 200d | 2027-04-06 | 2028-01-10 | 96SS+15d | 207d |  |
| 103 | 1.7.5 | **6.5. Edificios y talleres** | 200d | 2027-11-16 | 2028-08-21 |  | 47d |  |
| 104 | 1.7.5.1 | 6.5.1. Taller de mantenimiento | 50d | 2027-11-16 | 2028-01-24 | 91, 101 | 47d | 0d |
| 105 | 1.7.5.2 | 6.5.2. Edificio Administrativo | 50d | 2028-01-25 | 2028-04-03 | 104 | 47d | 0d |
| 106 | 1.7.5.3 | 6.5.3. Edificio INCOP | 50d | 2028-04-04 | 2028-06-12 | 105 | 47d | 0d |
| 107 | 1.7.5.4 | 6.5.4. Edificio CFS | 50d | 2028-06-13 | 2028-08-21 | 106 | 47d |  |

| ID | WBS | Task | Duration | Start | Finish | Predecessors | Total slack | Free slack |
| --- | --- | --- | --- | --- | --- | --- | --- | --- |
| 108 | 1.7.6 | **6.6. Equipamiento** | 100d | 2028-06-08 | 2028-10-25 |  | 0d |  |
| 109 | 1.7.6.1 | 6.6.1. Montaje Grúas STS (3) | 90d | 2028-06-08 | 2028-10-11 | 43, 97 | 10d |  |
| 110 | 1.7.6.2 | 6.6.2. Grúas RTG (17) | 100d | 2028-06-08 | 2028-10-25 | 43, 94 | 0d |  |
| 111 | 1.7.6.3 | 6.6.3. Tractor-Trailers (22) | 15d | 2028-06-08 | 2028-06-28 | 43, 94 | 85d |  |
| 112 | 1.8 | **7. Fase 1 Terminal de Contenedores Segunda mitad (280 m aprox)** | 452d | 2028-02-29 | 2029-11-21 |  | 0d |  |
| 113 | 1.8.1 | **7.1. Demoliciones** | 50d | 2028-10-26 | 2029-01-03 |  | 0d |  |
| 114 | 1.8.1.1 | 7.1.1. Demolición de bodegas | 50d | 2028-10-26 | 2029-01-03 | 87 | 0d |  |
| 115 | 1.8.1.2 | 7.1.2. Desarme frente de atraque (Incl. Defensas existentes) | 30d | 2028-10-26 | 2028-12-06 | 87 | 250d |  |
| 116 | 1.8.2 | **7.2. Pavimentos** | 230d | 2029-01-04 | 2029-11-21 |  | 0d |  |
| 117 | 1.8.2.1 | 7.2.1. Tratamiento y demolición de pavimentos | 100d | 2029-01-04 | 2029-05-23 | 114 | 0d |  |
| 118 | 1.8.2.2 | 7.2.2. Pavimentos (circulación interna) | 65d | 2029-05-24 | 2029-08-22 | 117 | 0d |  |
| 119 | 1.8.2.3 | 7.2.3. Pavimentos (patio contenedores) | 65d | 2029-08-23 | 2029-11-21 | 118 | 0d |  |
| 120 | 1.8.3 | **7.3. Nuevo frente de atraque** | 230d | 2028-02-29 | 2029-01-15 |  | 222d | 25d |
| 121 | 1.8.3.1 | 7.3.1. Hinca pilotes | 160d | 2028-02-29 | 2028-10-09 | 143 | 222d | 0d |
| 122 | 1.8.3.2 | 7.3.2. Confección losa hormigon | 185d | 2028-04-11 | 2028-12-25 | 121SS+30d | 222d | 0d |
| 123 | 1.8.3.3 | 7.3.3. Colocación defensas | 50d | 2028-11-07 | 2029-01-15 | 122SS+150d | 222d | 0d |
| 124 | 1.8.3.4 | 7.3.4. Colocación bitas | 10d | 2029-01-02 | 2029-01-15 | 123SS+40d | 222d |  |
| 125 | 1.8.4 | **7.4. Relleno explanada** | 195d | 2028-04-11 | 2029-01-08 |  | 227d |  |
| 126 | 1.8.4.1 | 7.4.1. Relleno explanada | 65d | 2028-04-11 | 2028-07-10 | 121SS+30d, 122SS | 357d |  |
| 127 | 1.8.4.2 | 7.4.2. Enrocado protección | 185d | 2028-04-25 | 2029-01-08 | 121SS+40d | 227d |  |
| 128 | 1.9 | **9. Mejoramiento Terminal de Graneles** | 279d | 2027-02-02 | 2028-02-25 |  | 222d |  |
| 129 | 1.9.1 | **9.1. Reparaciones y mejoramiento muelle existente** | 120d | 2027-02-02 | 2027-07-19 |  | 732d | 415d |
| 130 | 1.9.1.1 | 9.1.1. Reparaciones hormigón y frente de atraque | 100d | 2027-02-02 | 2027-06-21 | 59 | 732d | 0d |
| 131 | 1.9.1.2 | 9.1.2. Instalación grúa MHC | 20d | 2027-06-22 | 2027-07-19 | 130 | 732d |  |

| ID | WBS | Task | Duration | Start | Finish | Predecessors | Total slack | Free slack |
| --- | --- | --- | --- | --- | --- | --- | --- | --- |
| 132 | 1.9.2 | **9.2. Postes de amarre** | 85d | 2027-02-02 | 2027-05-31 |  | 222d |  |
| 133 | 1.9.2.1 | 9.2.1. Hinca de pilotes | 20d | 2027-02-02 | 2027-03-01 | 59, 86SS+50d | 222d | 0d |
| 134 | 1.9.2.2 | 9.2.2. Hormigonado | 40d | 2027-03-02 | 2027-04-26 | 133 | 657d | 0d |
| 135 | 1.9.2.3 | 9.2.3. Montaje ganchos de escape | 10d | 2027-05-18 | 2027-05-31 | 134FS+15d | 657d | 194d |
| 136 | 1.9.3 | **9.3. Nueva explanada almacenes** | 279d | 2027-02-02 | 2028-02-25 |  | 463d |  |
| 137 | 1.9.3.1 | 9.3.1. Enrocado de protección | 123d | 2027-08-10 | 2028-01-27 | 138SS+135d | 694d |  |
| 138 | 1.9.3.2 | 9.3.2. Relleno explanada | 248d | 2027-02-02 | 2028-01-13 | 59 | 463d | 0d |
| 139 | 1.9.3.3 | 9.3.4. Vías de circulación interna | 16d | 2028-01-14 | 2028-02-04 | 138 | 463d | 0d |
| 140 | 1.9.3.4 | 9.3.5. Gates de acceso | 15d | 2028-02-07 | 2028-02-25 | 139 | 463d | 0d |
| 141 | 1.10 | **10. Ampliación Terminal de Graneles Fase** | 385d | 2027-08-31 | 2029-02-19 |  | 222d |  |
| 142 | 1.10.1 | **10.1. Sitio nuevo** | 154d | 2027-08-31 | 2028-03-31 |  | 222d |  |
| 143 | 1.10.1.1 | 10.1.1. Hinca pilotes | 130d | 2027-08-31 | 2028-02-28 | 159 | 222d | 0d |
| 144 | 1.10.1.2 | 10.1.2. Hormigonado losa muelle | 104d | 2027-09-21 | 2028-02-11 | 143SS+15d | 548d | 0d |
| 145 | 1.10.1.3 | 10.1.3. Montaje Bitas y defensas | 35d | 2028-02-14 | 2028-03-31 | 144 | 548d |  |
| 146 | 1.10.2 | **10.2. Puente acceso** | 146d | 2027-12-07 | 2028-06-27 |  | 486d | 169d |
| 147 | 1.10.2.1 | 10.2.1. Hinca pilotes | 100d | 2027-12-07 | 2028-04-24 | 96 | 486d | 0d |
| 148 | 1.10.2.2 | 10.2.2. Hormigon losa puente acceso | 46d | 2028-04-25 | 2028-06-27 | 147 | 486d | 0d |
| 149 | 1.10.3 | **10.3. Postes de amarre** | 95d | 2028-10-10 | 2029-02-19 |  | 317d | 0d |
| 150 | 1.10.3.1 | 10.3.1. Hinca de pilotes | 40d | 2028-10-10 | 2028-12-04 | 121 | 317d | 0d |
| 151 | 1.10.3.2 | 10.3.2. Hormigonado | 20d | 2028-12-05 | 2029-01-01 | 150 | 317d | 0d |
| 152 | 1.10.3.3 | 10.3.3. Montaje ganchos de escape | 20d | 2029-01-23 | 2029-02-19 | 151FS+15d | 317d |  |
| 153 | 1.10.4 | **10.4. Equipamiento** | 60d | 2028-06-28 | 2028-09-19 |  | 526d |  |
| 154 | 1.10.4.1 | 10.4.1. Grúas MHC | 60d | 2028-06-28 | 2028-09-19 | 148 | 526d |  |
| 155 | 1.10.4.2 | 10.4.2. Tolvas de descarga | 60d | 2028-06-28 | 2028-09-19 | 148 | 526d |  |
| 156 | 1.10.4.3 | 10.4.5. Romana pesaje acceso y salida | 60d | 2028-06-28 | 2028-09-19 | 148 | 526d |  |

| ID | WBS | Task | Duration | Start | Finish | Predecessors | Total slack | Free slack |
| --- | --- | --- | --- | --- | --- | --- | --- | --- |
| 157 | 1.11 | **11. Terminal de Carga General** | 500d | 2027-03-02 | 2029-01-29 |  | 222d |  |
| 158 | 1.11.1 | **11.1. Construcción nuevo muelle** | 300d | 2027-03-02 | 2028-04-24 |  | 222d | 215d |
| 159 | 1.11.1.1 | 11.1.1. Hinca pilotes | 130d | 2027-03-02 | 2027-08-30 | 133 | 222d | 0d |
| 160 | 1.11.1.2 | 11.1.2. Hormigonado losa muelle | 135d | 2027-08-31 | 2028-03-06 | 159 | 532d | 0d |
| 161 | 1.11.1.3 | 11.1.3. Montaje Bitas y defensas | 35d | 2028-03-07 | 2028-04-24 | 160 | 532d |  |
| 162 | 1.11.2 | **11.2. Postes de amarre** | 55d | 2027-08-31 | 2027-11-15 |  | 647d | 330d |
| 163 | 1.11.2.1 | 11.2.1. Hinca de pilotes | 20d | 2027-08-31 | 2027-09-27 | 159 | 647d | 0d |
| 164 | 1.11.2.2 | 11.2.2. Hormigonado | 10d | 2027-09-28 | 2027-10-11 | 163 | 647d | 0d |
| 165 | 1.11.2.3 | 11.2.3. Montaje ganchos de escape | 10d | 2027-11-02 | 2027-11-15 | 164FS+15d | 647d |  |
| 166 | 1.11.3 | **11.3. Explanada** | 440d | 2027-03-02 | 2028-11-06 |  | 342d |  |
| 167 | 1.11.3.1 | 11.3.1. Relleno explanada | 200d | 2027-03-02 | 2027-12-06 | 159SS | 342d | 0d |
| 168 | 1.11.3.2 | 11.3.2. Enrocado de protección | 200d | 2027-04-27 | 2028-01-31 | 167SS+40d | 342d | 0d |
| 169 | 1.11.3.3 | 11.3.3. Pavimentos (circulación interna) | 100d | 2028-02-01 | 2028-06-19 | 168 | 342d | 0d |
| 170 | 1.11.3.4 | 11.3.4. Pavimentos (patio) | 100d | 2028-06-20 | 2028-11-06 | 169 | 342d | 0d |
| 171 | 1.11.4 | **11.4. Equipamiento** | 60d | 2028-11-07 | 2029-01-29 |  | 342d |  |
| 172 | 1.11.4.1 | 11.4.1. Grúas MHC | 60d | 2028-11-07 | 2029-01-29 | 43, 170 | 342d | 0d |
| 173 | 1.12 | **12. Muelle Auxiliar** | 100d | 2029-02-20 | 2029-07-09 |  | 317d |  |
| 174 | 1.12.1 | 11.5.1. Muelle auxuliar lanchas y remolcadores | 100d | 2029-02-20 | 2029-07-09 | 120, 129, 132, 142, 146, 149, 158, 162 | 317d |  |
| 175 | 1.13 | **13. Actividades de cierre** | 673d | 2028-02-28 | 2030-09-25 |  | 0d |  |
| 176 | 1.13.1 | **13.1. Fase 1 Terminal de graneles** | 180d | 2028-02-28 | 2028-11-03 |  | 463d |  |
| 177 | 1.13.1.1 | 13.1.1. Precommissioning | 90d | 2028-02-28 | 2028-06-30 | 134, 135, 140 | 463d | 0d |
| 178 | 1.13.1.2 | 13.1.2. Commisionning y pruebas finales | 60d | 2028-07-03 | 2028-09-22 | 177 | 463d | 0d |
| 179 | 1.13.1.3 | 13.1.3. Puesta en marcha | 30d | 2028-09-25 | 2028-11-03 | 178 | 463d | 0d |
| 180 | 1.13.2 | **13.2. Fase 1 Terminal de contenedores (primera mitad)** | 190d | 2028-10-26 | 2029-07-18 |  | 310d |  |
| 181 | 1.13.2.1 | 13.2.1. Precommissioning | 100d | 2028-10-26 | 2029-03-14 | 87 | 310d | 0d |
| 182 | 1.13.2.2 | 13.2.2. Commisionning y pruebas finales | 60d | 2029-03-15 | 2029-06-06 | 181 | 310d | 0d |
| 183 | 1.13.2.3 | 13.2.3. Puesta en marcha | 30d | 2029-06-07 | 2029-07-18 | 182 | 310d |  |

| ID | WBS | Task | Duration | Start | Finish | Predecessors | Total slack | Free slack |
| --- | --- | --- | --- | --- | --- | --- | --- | --- |
| 184 | 1.13.3 | **13.3. Fase 1 Terminal de contenedores (segunda mitad)** | 190d | 2029-11-22 | 2030-08-14 |  | 0d |  |
| 185 | 1.13.3.1 | 13.3.1. Precommissioning | 100d | 2029-11-22 | 2030-04-10 | 112 | 0d |  |
| 186 | 1.13.3.2 | 13.3.2. Commisionning y pruebas finales | 60d | 2030-04-11 | 2030-07-03 | 185 | 0d |  |
| 187 | 1.13.3.3 | 13.3.3. Puesta en marcha | 30d | 2030-07-04 | 2030-08-14 | 186 | 0d |  |
| 188 | 1.13.4 | **13.4. Fase 1 Terminal de Carga General** | 60d | 2029-01-30 | 2029-04-23 |  | 342d |  |
| 189 | 1.13.4.1 | 13.4.1. Precommissioning | 20d | 2029-01-30 | 2029-02-26 | 172 | 342d | 0d |
| 190 | 1.13.4.2 | 13.4.2. Commisionning y pruebas finales | 20d | 2029-02-27 | 2029-03-26 | 189 | 342d | 0d |
| 191 | 1.13.4.3 | 13.4.3. Puesta en marcha | 20d | 2029-03-27 | 2029-04-23 | 190 | 342d | 0d |
| 192 | 1.13.5 | **13.5. Desmovilización General** | 30d | 2030-08-15 | 2030-09-25 |  | 0d |  |
| 193 | 1.13.5.1 | 13.5.1 Desmovilización | 30d | 2030-08-15 | 2030-09-25 | 179, 187, 191 | 0d |  |
